# Ny butik

How a schedule from MS Project changed from version to version. A marks actual dates.

## Version 1 (saved 2013-09-11, file 11A - Ny visning.mpp)

| ID | WBS | Task | Duration | Start | Finish | Predecessors | Total float |
| --- | --- | --- | --- | --- | --- | --- | --- |
| 1 |  | Start | 0d | 2013-08-26 | 2013-08-26 |  | 1d |
| 2 |  | Tegning | 3d | 2013-08-26 | 2013-08-28 | 1 | 1d |
| 3 | 3 | **Fundament** | 7d | 2013-08-29 | 2013-09-07 | 2 | 0d |
| 4 |  | Udgravning | 2d | 2013-08-29 | 2013-08-30 |  | 1d |
| 5 |  | Støbning | 1d | 2013-09-02 | 2013-09-02 | 4 | 1d |
| 6 |  | Afbinding | 5ed | 2013-09-02 | 2013-09-07 | 5 | 4.88d |
| 7 | 4 | **Råhus** | 4.25d | 2013-09-09 | 2013-09-13 | 6 | 0d |
| 8 |  | Bærende konstruktioner | 3d | 2013-09-09 | 2013-09-11 |  | 0d |
| 9 |  | Ydervægge | 2d | 2013-09-11 | 2013-09-13 | 8FS-2.5% | 0d |
| 10 |  | Tag | 2d | 2013-09-11 | 2013-09-13 | 9SS | 0d |
| 11 |  | Rejsegilde | 0d | 2013-09-13 | 2013-09-13 | 9, 10 | 0d |
| 12 |  | Taglægning | 10d | 2013-09-13 | 2013-09-27 | 11 | 0d |
| 13 |  | Døre og vinduer | 2d | 2013-09-13 | 2013-09-17 | 12SS | 5d |
| 14 |  | Faskine | 2d | 2013-09-03 | 2013-09-04 | 5 | 12d |
| 15 |  | Tagrender | 5h | 2013-09-13 | 2013-09-13 | 13SS, 14 | 5.75d |
| 16 |  | Maling udvendigt | 10h | 2013-09-13 | 2013-09-17 | 15 | 5.75d |
| 17 |  | Gulv | 1d | 2013-09-17 | 2013-09-18 | 13, 16FS-5% | 5d |
| 18 |  | Maling indvendigt | 2d | 2013-09-25 | 2013-09-27 | 12FF, 17 | 0d |
| 19 |  | Indvielse | 0d | 2013-09-30 | 2013-09-30 | 13, 18FS+1d | 0d |

## Version 2 (saved 2017-05-24, file 15 - Butik i Hiller沝.mpp)

Last finish 2013-09-30 → 2017-06-27 (+1366d).

Changed:

| ID | Task | Start | Finish | Duration | Total float | Other |
| --- | --- | --- | --- | --- | --- | --- |
| 1 | start | 2013-08-26 → 2017-05-24 (+1367d) | 2013-08-26 → 2017-05-24 (+1367d) |  | 1d → 0d | was named Start |
| 2 | Tegning | 2013-08-26 → 2017-05-24 (+1367d) | 2013-08-28 → 2017-05-26 (+1367d) |  | 1d → 0d | resources Arkitekt Arne [50%] → none |
| 3 | **Fundament** | 2013-08-29 → 2017-05-29 (+1369d) | 2013-09-07 → 2017-06-05 (+1367d) | 7d → 6d |  |  |
| 4 | Udgravning | 2013-08-29 → 2017-05-29 (+1369d) | 2013-08-30 → 2017-05-30 (+1369d) |  | 1d → 0d | resources Gravemaskine; Jord og beton Jette → none |
| 5 | Støbning | 2013-09-02 → 2017-05-31 (+1367d) | 2013-09-02 → 2017-05-31 (+1367d) |  | 1d → 0d | resources Betonblander; Jord og beton Jette → none |
| 6 | Afbinding | 2013-09-02 → 2017-05-31 (+1367d) | 2013-09-07 → 2017-06-05 (+1367d) |  | 4.88d → 1.88d |  |
| 7 | **Råhus** | 2013-09-09 → 2017-06-06 (+1366d) | 2013-09-13 → 2017-06-12 (+1368d) |  |  |  |
| 8 | Bærende konstruktioner | 2013-09-09 → 2017-06-06 (+1366d) | 2013-09-11 → 2017-06-08 (+1366d) |  |  | resources Tømrer Tom [25%] → none |
| 9 | Ydervægge | 2013-09-11 → 2017-06-08 (+1366d) | 2013-09-13 → 2017-06-12 (+1368d) |  |  | resources Murer Mads → none |
| 10 | Tag | 2013-09-11 → 2017-06-08 (+1366d) | 2013-09-13 → 2017-06-12 (+1368d) |  |  | resources Tømrer Tom [25%] → none |
| 11 | Rejsegilde | 2013-09-13 → 2017-06-12 (+1368d) | 2013-09-13 → 2017-06-12 (+1368d) |  |  |  |
| 12 | Taglægning | 2013-09-13 → 2017-06-12 (+1368d) | 2013-09-27 → 2017-06-26 (+1368d) |  |  | resources Tømrer Tom [50%] → none |
| 13 | Døre og vinduer | 2013-09-13 → 2017-06-12 (+1368d) | 2013-09-17 → 2017-06-14 (+1366d) |  |  | resources Snedker Susanne [25%] → none |
| 14 | Faskine | 2013-09-03 → 2017-06-01 (+1367d) | 2013-09-04 → 2017-06-02 (+1367d) |  | 12d → 11d | resources Gravemaskine; Jord og beton Jette → none |
| 15 | Tagrender | 2013-09-13 → 2017-06-12 (+1368d) | 2013-09-13 → 2017-06-12 (+1368d) |  |  | resources VVS Victoria [25%] → none |
| 16 | Maling udvendigt | 2013-09-13 → 2017-06-12 (+1368d) | 2013-09-17 → 2017-06-14 (+1366d) |  |  | resources Maler Morten → none |
| 17 | Gulv | 2013-09-17 → 2017-06-14 (+1366d) | 2013-09-18 → 2017-06-15 (+1366d) |  |  | resources Snedker Susanne [25%] → none |
| 18 | Maling indvendigt | 2013-09-25 → 2017-06-22 (+1366d) | 2013-09-27 → 2017-06-26 (+1368d) |  |  | resources Maler Morten → none |
| 19 | Indvielse | 2013-09-30 → 2017-06-27 (+1366d) | 2013-09-30 → 2017-06-27 (+1366d) |  |  |  |

## Version 3 (saved 2017-05-24, file 15 - Butik i N憇tved.mpp)

Last finish 2017-06-27 → 2017-07-31 (+34d).

Changed:

| ID | Task | Start | Finish | Duration | Total float |
| --- | --- | --- | --- | --- | --- |
| 1 | start | 2017-05-24 → 2017-06-24 (+31d) | 2017-05-24 → 2017-06-24 (+31d) |  | 0d → 1d |
| 2 | Tegning | 2017-05-24 → 2017-06-26 (+33d) | 2017-05-26 → 2017-06-28 (+33d) |  | 0d → 1d |
| 3 | **Fundament** | 2017-05-29 → 2017-06-29 (+31d) | 2017-06-05 → 2017-07-08 (+33d) | 6d → 7d |  |
| 4 | Udgravning | 2017-05-29 → 2017-06-29 (+31d) | 2017-05-30 → 2017-06-30 (+31d) |  | 0d → 1d |
| 5 | Støbning | 2017-05-31 → 2017-07-03 (+33d) | 2017-05-31 → 2017-07-03 (+33d) |  | 0d → 1d |
| 6 | Afbinding | 2017-05-31 → 2017-07-03 (+33d) | 2017-06-05 → 2017-07-08 (+33d) |  | 1.88d → 4.88d |
| 7 | **Råhus** | 2017-06-06 → 2017-07-10 (+34d) | 2017-06-12 → 2017-07-14 (+32d) |  |  |
| 8 | Bærende konstruktioner | 2017-06-06 → 2017-07-10 (+34d) | 2017-06-08 → 2017-07-12 (+34d) |  |  |
| 9 | Ydervægge | 2017-06-08 → 2017-07-12 (+34d) | 2017-06-12 → 2017-07-14 (+32d) |  |  |
| 10 | Tag | 2017-06-08 → 2017-07-12 (+34d) | 2017-06-12 → 2017-07-14 (+32d) |  |  |
| 11 | Rejsegilde | 2017-06-12 → 2017-07-14 (+32d) | 2017-06-12 → 2017-07-14 (+32d) |  |  |
| 12 | Taglægning | 2017-06-12 → 2017-07-14 (+32d) | 2017-06-26 → 2017-07-28 (+32d) |  |  |
| 13 | Døre og vinduer | 2017-06-12 → 2017-07-14 (+32d) | 2017-06-14 → 2017-07-18 (+34d) |  |  |
| 14 | Faskine | 2017-06-01 → 2017-07-04 (+33d) | 2017-06-02 → 2017-07-05 (+33d) |  | 11d → 12d |
| 15 | Tagrender | 2017-06-12 → 2017-07-14 (+32d) | 2017-06-12 → 2017-07-14 (+32d) |  |  |
| 16 | Maling udvendigt | 2017-06-12 → 2017-07-14 (+32d) | 2017-06-14 → 2017-07-18 (+34d) |  |  |
| 17 | Gulv | 2017-06-14 → 2017-07-18 (+34d) | 2017-06-15 → 2017-07-19 (+34d) |  |  |
| 18 | Maling indvendigt | 2017-06-22 → 2017-07-26 (+34d) | 2017-06-26 → 2017-07-28 (+32d) |  |  |
| 19 | Indvielse | 2017-06-27 → 2017-07-31 (+34d) | 2017-06-27 → 2017-07-31 (+34d) |  |  |

## Version 4 (saved 2017-05-24, file 15 - Butik i Slagelse.mpp)

Last finish 2017-07-31 → 2017-06-05 (-56d).

Changed:

| ID | Task | Start | Finish | Duration | Total float |
| --- | --- | --- | --- | --- | --- |
| 1 | start | 2017-06-24 → 2017-05-02 (-53d) | 2017-06-24 → 2017-05-02 (-53d) |  | 1d → 0d |
| 2 | Tegning | 2017-06-26 → 2017-05-02 (-55d) | 2017-06-28 → 2017-05-04 (-55d) |  | 1d → 0d |
| 3 | **Fundament** | 2017-06-29 → 2017-05-05 (-55d) | 2017-07-08 → 2017-05-14 (-55d) | 7d → 6d |  |
| 4 | Udgravning | 2017-06-29 → 2017-05-05 (-55d) | 2017-06-30 → 2017-05-08 (-53d) |  | 1d → 0d |
| 5 | Støbning | 2017-07-03 → 2017-05-09 (-55d) | 2017-07-03 → 2017-05-09 (-55d) |  | 1d → 0d |
| 6 | Afbinding | 2017-07-03 → 2017-05-09 (-55d) | 2017-07-08 → 2017-05-14 (-55d) |  | 4.88d → 1.88d |
| 7 | **Råhus** | 2017-07-10 → 2017-05-15 (-56d) | 2017-07-14 → 2017-05-19 (-56d) |  |  |
| 8 | Bærende konstruktioner | 2017-07-10 → 2017-05-15 (-56d) | 2017-07-12 → 2017-05-17 (-56d) |  |  |
| 9 | Ydervægge | 2017-07-12 → 2017-05-17 (-56d) | 2017-07-14 → 2017-05-19 (-56d) |  |  |
| 10 | Tag | 2017-07-12 → 2017-05-17 (-56d) | 2017-07-14 → 2017-05-19 (-56d) |  |  |
| 11 | Rejsegilde | 2017-07-14 → 2017-05-19 (-56d) | 2017-07-14 → 2017-05-19 (-56d) |  |  |
| 12 | Taglægning | 2017-07-14 → 2017-05-19 (-56d) | 2017-07-28 → 2017-06-02 (-56d) |  |  |
| 13 | Døre og vinduer | 2017-07-14 → 2017-05-19 (-56d) | 2017-07-18 → 2017-05-23 (-56d) |  |  |
| 14 | Faskine | 2017-07-04 → 2017-05-10 (-55d) | 2017-07-05 → 2017-05-11 (-55d) |  | 12d → 11d |
| 15 | Tagrender | 2017-07-14 → 2017-05-19 (-56d) | 2017-07-14 → 2017-05-19 (-56d) |  |  |
| 16 | Maling udvendigt | 2017-07-14 → 2017-05-19 (-56d) | 2017-07-18 → 2017-05-23 (-56d) |  |  |
| 17 | Gulv | 2017-07-18 → 2017-05-23 (-56d) | 2017-07-19 → 2017-05-24 (-56d) |  |  |
| 18 | Maling indvendigt | 2017-07-26 → 2017-05-31 (-56d) | 2017-07-28 → 2017-06-02 (-56d) |  |  |
| 19 | Indvielse | 2017-07-31 → 2017-06-05 (-56d) | 2017-07-31 → 2017-06-05 (-56d) |  |  |

## Version 5 (saved 2017-05-24, file 07A - Ny butik i 弐hus.mpp)

Last finish 2017-06-05 → 2017-08-28 (+84d).

Changed:

| ID | Task | Start | Finish | Duration | Total float | Other |
| --- | --- | --- | --- | --- | --- | --- |
| 1 | start | 2017-05-02 → 2017-07-21 (+80d) | 2017-05-02 → 2017-07-21 (+80d) |  | 0d → 0.38d |  |
| 2 | Tegning | 2017-05-02 → 2017-07-21 (+80d) | 2017-05-04 → 2017-07-27 (+84d) |  | 0d → 0.12d | resources none → Arkitekt Arne |
| 3 | **Fundament** | 2017-05-05 → 2017-07-27 (+83d) | 2017-05-14 → 2017-08-06 (+84d) | 6d → 6.25d |  |  |
| 4 | Udgravning | 2017-05-05 → 2017-07-27 (+83d) | 2017-05-08 → 2017-07-31 (+84d) |  | 0d → 0.25d | resources none → Jord og beton Jette; Gravemaskine |
| 5 | Støbning | 2017-05-09 → 2017-07-31 (+83d) | 2017-05-09 → 2017-08-01 (+84d) |  | 0d → 0.25d | resources none → Jord og beton Jette; Betonblander |
| 6 | Afbinding | 2017-05-09 → 2017-08-01 (+84d) | 2017-05-14 → 2017-08-06 (+84d) |  | 1.88d → 2.12d |  |
| 7 | **Råhus** | 2017-05-15 → 2017-08-07 (+84d) | 2017-05-19 → 2017-08-11 (+84d) | 4.25d → 4.5d |  |  |
| 8 | Bærende konstruktioner | 2017-05-15 → 2017-08-07 (+84d) | 2017-05-17 → 2017-08-09 (+84d) |  |  | resources none → Tømrer Tom |
| 9 | Ydervægge | 2017-05-17 → 2017-08-09 (+84d) | 2017-05-19 → 2017-08-11 (+84d) |  |  | resources none → Murer Mads |
| 10 | Tag | 2017-05-17 → 2017-08-09 (+84d) | 2017-05-19 → 2017-08-11 (+84d) |  |  | resources none → Snedker Susanne |
| 11 | Rejsegilde | 2017-05-19 → 2017-08-11 (+84d) | 2017-05-19 → 2017-08-11 (+84d) |  |  | resources none → Arkitekt Arne; Jord og beton Jette; Maler Morten; Murer Mads; Snedker Susanne; Tømrer Tom; VVS Victoria |
| 12 | Taglægning | 2017-05-19 → 2017-08-11 (+84d) | 2017-06-02 → 2017-08-25 (+84d) |  |  | resources none → Tømrer Tom |
| 13 | Døre og vinduer | 2017-05-19 → 2017-08-11 (+84d) | 2017-05-23 → 2017-08-15 (+84d) |  | 5d → 4.62d | resources none → Snedker Susanne |
| 14 | Faskine | 2017-05-10 → 2017-08-01 (+83d) | 2017-05-11 → 2017-08-03 (+84d) |  | 11d → 11.38d | resources none → Jord og beton Jette; Gravemaskine |
| 15 | Tagrender | 2017-05-19 → 2017-08-11 (+84d) | 2017-05-19 → 2017-08-14 (+87d) |  | 5.75d → 5.62d | resources none → VVS Victoria |
| 16 | Maling udvendigt | 2017-05-19 → 2017-08-14 (+87d) | 2017-05-23 → 2017-08-15 (+84d) |  | 5.75d → 5.62d | resources none → Maler Morten |
| 17 | Gulv | 2017-05-23 → 2017-08-15 (+84d) | 2017-05-24 → 2017-08-16 (+84d) |  | 5d → 4.62d | resources none → Snedker Susanne |
| 18 | Maling indvendigt | 2017-05-31 → 2017-08-23 (+84d) | 2017-06-02 → 2017-08-25 (+84d) |  |  | resources none → Maler Morten |
| 19 | Indvielse | 2017-06-05 → 2017-08-28 (+84d) | 2017-06-05 → 2017-08-28 (+84d) |  |  | resources none → Arkitekt Arne; Jord og beton Jette; Maler Morten; Murer Mads; Snedker Susanne; Tømrer Tom; VVS Victoria |

## Version 6 (saved 2017-05-24, file 06B - Ny butik på Amagertorv.mpp)

Last finish 2017-08-28 → 2017-10-30 (+63d).

Added:

| ID | Task | Duration | Start | Finish |
| --- | --- | --- | --- | --- |
| 1 | Start | 0d | 2017-09-23 | 2017-09-23 |

Removed: 1 start

Changed:

| ID | Task | Start | Finish | Duration | Total float | Predecessors | Other |
| --- | --- | --- | --- | --- | --- | --- | --- |
| 2 | Tegning | 2017-07-21 → 2017-09-25 (+66d) | 2017-07-27 → 2017-09-27 (+62d) |  | 0.12d → 1d | start → 1 |  |
| 3 | **Fundament** | 2017-07-27 → 2017-09-28 (+63d) | 2017-08-06 → 2017-10-07 (+62d) | 6.25d → 7d |  |  |  |
| 4 | Udgravning | 2017-07-27 → 2017-09-28 (+63d) | 2017-07-31 → 2017-09-29 (+60d) |  | 0.25d → 1d |  |  |
| 5 | Støbning | 2017-07-31 → 2017-10-02 (+63d) | 2017-08-01 → 2017-10-02 (+62d) |  | 0.25d → 1d |  |  |
| 6 | Afbinding | 2017-08-01 → 2017-10-02 (+62d) | 2017-08-06 → 2017-10-07 (+62d) |  | 2.12d → 4.88d |  |  |
| 7 | **Råhus** | 2017-08-07 → 2017-10-09 (+63d) | 2017-08-11 → 2017-10-13 (+63d) |  |  |  |  |
| 8 | Bærende konstruktioner | 2017-08-07 → 2017-10-09 (+63d) | 2017-08-09 → 2017-10-11 (+63d) |  |  |  |  |
| 9 | Ydervægge | 2017-08-09 → 2017-10-11 (+63d) | 2017-08-11 → 2017-10-13 (+63d) |  |  |  |  |
| 10 | Tag | 2017-08-09 → 2017-10-11 (+63d) | 2017-08-11 → 2017-10-13 (+63d) |  |  |  |  |
| 11 | Rejsegilde | 2017-08-11 → 2017-10-13 (+63d) | 2017-08-11 → 2017-10-13 (+63d) |  |  |  | resources Arkitekt Arne; Jord og beton Jette; Maler Morten; Murer Mads; Snedker Susanne; Tømrer Tom; VVS Victoria → Jord og beton Jette; Maler Morten; Murer Mads; Snedker Susanne; Tømrer Tom; VVS Victoria |
| 12 | Taglægning | 2017-08-11 → 2017-10-13 (+63d) | 2017-08-25 → 2017-10-27 (+63d) |  |  |  |  |
| 13 | Døre og vinduer | 2017-08-11 → 2017-10-13 (+63d) | 2017-08-15 → 2017-10-17 (+63d) |  |  |  |  |
| 14 | Faskine | 2017-08-01 → 2017-10-03 (+63d) | 2017-08-03 → 2017-10-04 (+62d) |  | 11.38d → 12.12d |  |  |
| 15 | Tagrender | 2017-08-11 → 2017-10-13 (+63d) | 2017-08-14 → 2017-10-16 (+63d) |  |  |  |  |
| 16 | Maling udvendigt | 2017-08-14 → 2017-10-16 (+63d) | 2017-08-15 → 2017-10-17 (+63d) |  |  |  |  |
| 17 | Gulv | 2017-08-15 → 2017-10-17 (+63d) | 2017-08-16 → 2017-10-18 (+63d) |  |  |  |  |
| 18 | Maling indvendigt | 2017-08-23 → 2017-10-25 (+63d) | 2017-08-25 → 2017-10-27 (+63d) |  |  |  |  |
| 19 | Indvielse | 2017-08-28 → 2017-10-30 (+63d) | 2017-08-28 → 2017-10-30 (+63d) |  |  |  | resources Arkitekt Arne; Jord og beton Jette; Maler Morten; Murer Mads; Snedker Susanne; Tømrer Tom; VVS Victoria → Jord og beton Jette; Maler Morten; Murer Mads; Snedker Susanne; Tømrer Tom; VVS Victoria |

## Version 7 (saved 2019-11-13, file 06A - WBS.mpp)

Last finish 2017-10-30 → 2018-04-12 (+164d).

Removed: 1 Start

Changed:

| ID | Task | Start | Finish | Duration | Total float | Predecessors | Other |
| --- | --- | --- | --- | --- | --- | --- | --- |
| 1 | Tegning | 2017-09-25 → 2018-03-05 (+161d) | 2017-09-27 → 2018-03-09 (+163d) |  | 1d → 0d | Start → none |  |
| 2 | **Fundament** | 2017-09-28 → 2018-03-13 (+166d) | 2017-10-07 → 2018-03-21 (+165d) | 7d → 6d |  | 1 → 1FS+2d |  |
| 3 | Udgravning | 2017-09-28 → 2018-03-13 (+166d) | 2017-09-29 → 2018-03-15 (+167d) |  | 1d → 0d |  | resources Jord og beton Jette; Gravemaskine → Gravemaskine; Jord og beton Jette |
| 4 | Støbning | 2017-10-02 → 2018-03-15 (+164d) | 2017-10-02 → 2018-03-16 (+165d) |  | 1d → 0d |  |  |
| 5 | Afbinding | 2017-10-02 → 2018-03-16 (+165d) | 2017-10-07 → 2018-03-21 (+165d) |  | 4.88d → 0d |  |  |
| 6 | **Råhus** | 2017-10-09 → 2018-03-21 (+163d) | 2017-10-13 → 2018-03-28 (+166d) |  |  |  |  |
| 7 | Bærende konstruktioner | 2017-10-09 → 2018-03-21 (+163d) | 2017-10-11 → 2018-03-26 (+166d) |  |  |  |  |
| 8 | Ydervægge | 2017-10-11 → 2018-03-26 (+166d) | 2017-10-13 → 2018-03-27 (+165d) |  |  |  |  |
| 9 | Tagkonstruktioner | 2017-10-11 → 2018-03-26 (+166d) | 2017-10-13 → 2018-03-28 (+166d) |  |  |  | was named Tag |
| 10 | Rejsegilde | 2017-10-13 → 2018-03-28 (+166d) | 2017-10-13 → 2018-03-28 (+166d) |  |  | 9, 8 → 9 | resources Jord og beton Jette; Maler Morten; Murer Mads; Snedker Susanne; Tømrer Tom; VVS Victoria → Arkitekt Arne; Jord og beton Jette; Maler Morten; Murer Mads; Snedker Susanne; Tømrer Tom; VVS Victoria |
| 11 | Taglægning | 2017-10-13 → 2018-03-28 (+166d) | 2017-10-27 → 2018-04-11 (+166d) |  |  |  |  |
| 12 | Døre og vinduer | 2017-10-13 → 2018-03-28 (+166d) | 2017-10-17 → 2018-03-30 (+164d) |  | 4.62d → 4.5d |  |  |
| 13 | Faskine | 2017-10-03 → 2018-03-16 (+164d) | 2017-10-04 → 2018-03-20 (+167d) |  | 12.12d → 11.12d |  | resources Jord og beton Jette; Gravemaskine → Gravemaskine; Jord og beton Jette |
| 14 | Tagrender | 2017-10-13 → 2018-03-28 (+166d) | 2017-10-16 → 2018-03-28 (+163d) |  |  |  |  |
| 15 | Maling udvendigt | 2017-10-16 → 2018-03-28 (+163d) | 2017-10-17 → 2018-03-30 (+164d) |  |  |  |  |
| 16 | Gulv | 2017-10-17 → 2018-03-30 (+164d) | 2017-10-18 → 2018-04-02 (+166d) |  |  |  |  |
| 17 | Maling indvendigt | 2017-10-25 → 2018-04-09 (+166d) | 2017-10-27 → 2018-04-11 (+166d) |  |  |  |  |
| 18 | Indvielse | 2017-10-30 → 2018-04-12 (+164d) | 2017-10-30 → 2018-04-12 (+164d) |  |  | 17FS+1d, 12 → 17FS+1d | resources Jord og beton Jette; Maler Morten; Murer Mads; Snedker Susanne; Tømrer Tom; VVS Victoria → Jord og beton Jette; Maler Morten; Murer Mads; Snedker Susanne; Tømrer Tom; VVS Victoria; Arkitekt Arne |

## Version 8 (saved 2019-12-13, file 10 - F沨n og Kl慼m.mpp)

Last finish 2018-04-12 → 2015-05-07 (-1071d).

Added:

| ID | Task | Duration | Start | Finish | Predecessors | Resources |
| --- | --- | --- | --- | --- | --- | --- |
| 2 | Projektgodkendelse | 2d | 2015-03-20 | 2015-03-24 | 1 |  |
| 3 | Ansøgning om byggetilladelse | 5d | 2015-03-24 | 2015-03-31 | 2 |  |
| 4 | Byggesagsbehandling | 5d | 2015-03-31 | 2015-04-07 | 3 |  |
| 13 | Rejsgilde | 0d | 2015-04-22 | 2015-04-22 | 12 | Arkitekt Arne; Jord og beton Jette; Maler Morten; Murer Mads; Snedker Susanne; Tømrer Tom; VVS Victoria |

Removed: 10 Rejsegilde

Changed:

| ID | Task | Start | Finish | Predecessors | Other |
| --- | --- | --- | --- | --- | --- |
| 1 | Tegning | 2018-03-05 → 2015-03-16 (-1085d) | 2018-03-09 → 2015-03-20 (-1085d) |  |  |
| 5 | **Fundament** | 2018-03-13 → 2015-04-07 (-1071d) | 2018-03-21 → 2015-04-15 (-1071d) | 1FS+2d → 4 |  |
| 6 | Udgravning | 2018-03-13 → 2015-04-07 (-1071d) | 2018-03-15 → 2015-04-09 (-1071d) |  | resources Gravemaskine; Jord og beton Jette → Jord og beton Jette; Gravemaskine |
| 7 | Støbning | 2018-03-15 → 2015-04-09 (-1071d) | 2018-03-16 → 2015-04-10 (-1071d) |  |  |
| 8 | Afbinding | 2018-03-16 → 2015-04-10 (-1071d) | 2018-03-21 → 2015-04-15 (-1071d) |  |  |
| 9 | **Råhus** | 2018-03-21 → 2015-04-15 (-1071d) | 2018-03-28 → 2015-04-22 (-1071d) |  |  |
| 10 | Bærende konstruktioner | 2018-03-21 → 2015-04-15 (-1071d) | 2018-03-26 → 2015-04-20 (-1071d) |  |  |
| 11 | Ydervægge | 2018-03-26 → 2015-04-20 (-1071d) | 2018-03-27 → 2015-04-21 (-1071d) |  |  |
| 12 | Tagkonstruktioner | 2018-03-26 → 2015-04-20 (-1071d) | 2018-03-28 → 2015-04-22 (-1071d) |  |  |
| 14 | Taglægning | 2018-03-28 → 2015-04-22 (-1071d) | 2018-04-11 → 2015-05-06 (-1071d) | Rejsegilde → 13 |  |
| 15 | Døre og vinduer | 2018-03-28 → 2015-04-22 (-1071d) | 2018-03-30 → 2015-04-24 (-1071d) |  |  |
| 16 | Faskine | 2018-03-16 → 2015-04-10 (-1071d) | 2018-03-20 → 2015-04-14 (-1071d) |  | resources Gravemaskine; Jord og beton Jette → Jord og beton Jette; Gravemaskine |
| 17 | Tagrender | 2018-03-28 → 2015-04-22 (-1071d) | 2018-03-28 → 2015-04-22 (-1071d) |  |  |
| 18 | Maling udvendigt | 2018-03-28 → 2015-04-22 (-1071d) | 2018-03-30 → 2015-04-24 (-1071d) |  |  |
| 19 | Gulv | 2018-03-30 → 2015-04-24 (-1071d) | 2018-04-02 → 2015-04-27 (-1071d) |  |  |
| 20 | Maling indvendigt | 2018-04-09 → 2015-05-04 (-1071d) | 2018-04-11 → 2015-05-06 (-1071d) |  |  |
| 21 | Indvielse | 2018-04-12 → 2015-05-07 (-1071d) | 2018-04-12 → 2015-05-07 (-1071d) |  | resources Jord og beton Jette; Maler Morten; Murer Mads; Snedker Susanne; Tømrer Tom; VVS Victoria; Arkitekt Arne → Arkitekt Arne; Jord og beton Jette; Maler Morten; Murer Mads; Snedker Susanne; Tømrer Tom; VVS Victoria |

## Version 9 (saved 2020-10-28, file 18C - Deltidskalender.mpp)

Last finish 2015-05-07 → 2019-07-31 (+1546d).

Added:

| ID | Task | Duration | Start | Finish | Predecessors | Resources |
| --- | --- | --- | --- | --- | --- | --- |
| 10 | Rejsegilde | 0d | 2019-07-12 | 2019-07-15 | 6 | Arkitekt Arne; Forplejning [10 Kuverter]; Jord og Beton Jette; Maler Morten; Murer Mads; Snedker Susanne; Tømrer Tom; Tømrer Torben; VVS Victoria |

Removed: 2 Projektgodkendelse; 3 Ansøgning om byggetilladelse; 4 Byggesagsbehandling; 13 Rejsgilde

Changed:

| ID | Task | Start | Finish | Duration | Total float | Predecessors | Other |
| --- | --- | --- | --- | --- | --- | --- | --- |
| 1 | Tegning | 2015-03-16 → 2019-06-20 (+1557d) | 2015-03-20 → 2019-06-26 (+1559d) |  |  |  |  |
| 2 | **Fundament** | 2015-04-07 → 2019-06-28 (+1543d) | 2015-04-15 → 2019-07-08 (+1545d) |  |  | Byggesagsbehandling → 1FS+2d |  |
| 3 | Udgravning | 2015-04-07 → 2019-06-28 (+1543d) | 2015-04-09 → 2019-07-02 (+1545d) |  |  |  | resources Jord og beton Jette; Gravemaskine → Gravemaskine; Jord og Beton Jette |
| 4 | Støbning | 2015-04-09 → 2019-07-02 (+1545d) | 2015-04-10 → 2019-07-03 (+1545d) |  |  |  | resources Jord og beton Jette; Betonblander → Beton [2 Kubikmeter]; Betonblander; Jord og Beton Jette |
| 5 | Afbinding | 2015-04-10 → 2019-07-03 (+1545d) | 2015-04-15 → 2019-07-08 (+1545d) |  |  |  |  |
| 6 | **Råhus** | 2015-04-15 → 2019-07-08 (+1545d) | 2015-04-22 → 2019-07-12 (+1542d) | 4.5d → 4.25d |  | 5 → 2 |  |
| 7 | Bærende konstruktioner | 2015-04-15 → 2019-07-08 (+1545d) | 2015-04-20 → 2019-07-11 (+1543d) |  |  |  | resources Tømrer Tom → Tømrer Torben |
| 8 | Ydervægge | 2015-04-20 → 2019-07-11 (+1543d) | 2015-04-21 → 2019-07-12 (+1543d) |  |  |  |  |
| 9 | Tagkonstruktioner | 2015-04-20 → 2019-07-11 (+1543d) | 2015-04-22 → 2019-07-12 (+1542d) |  |  |  | resources Snedker Susanne → Tømrer Tom |
| 11 | Taglægning | 2015-04-22 → 2019-07-16 (+1546d) | 2015-05-06 → 2019-07-29 (+1545d) |  |  | Rejsgilde → 10 |  |
| 12 | Døre og vinduer | 2015-04-22 → 2019-07-16 (+1546d) | 2015-04-24 → 2019-07-17 (+1545d) |  | 4.5d → 6.75d |  | resources Snedker Susanne → none |
| 13 | Faskine | 2015-04-10 → 2019-07-03 (+1545d) | 2015-04-14 → 2019-07-05 (+1543d) |  | 11.12d → 14.38d |  | resources Jord og beton Jette; Gravemaskine → Gravemaskine; Jord og Beton Jette |
| 14 | Tagrender | 2015-04-22 → 2019-07-16 (+1546d) | 2015-04-22 → 2019-07-16 (+1546d) |  | 5.62d → 8.12d |  |  |
| 15 | Maling udvendigt | 2015-04-22 → 2019-07-26 (+1556d) | 2015-04-24 → 2019-07-29 (+1557d) |  | 5.62d → 0d | 14 → 14, 11FF | resources Maler Morten → Maling [10 Liter]; Maler Morten |
| 16 | Maling indvendigt | 2015-05-04 → 2019-07-18 (+1536d) | 2015-05-06 → 2019-07-19 (+1535d) |  | 0d → 6.75d | 17, 11FF → 12 |  |
| 17 | Gulv | 2015-04-24 → 2019-07-19 (+1547d) | 2015-04-27 → 2019-07-22 (+1547d) |  | 4.62d → 6.75d | 15FS-5%, 12 → 16FS-5% |  |
| 18 | Invielse | 2015-05-07 → 2019-07-30 (+1545d) | 2015-05-07 → 2019-07-31 (+1546d) |  |  | 16FS+1d → 17, 15FS+1d | was named Indvielse; resources Arkitekt Arne; Jord og beton Jette; Maler Morten; Murer Mads; Snedker Susanne; Tømrer Tom; VVS Victoria → Arkitekt Arne; Betonblander; Forplejning [20 Kuverter]; Gravemaskine; Jord og Beton Jette; Maler Morten; Murer Mads; Snedker Susanne; Tømrer Tom; Tømrer Torben; VVS Victoria |

## Version 10 (saved 2020-10-30, file 05B – Opfølgning II.mpp)

Last finish 2019-07-31 → 2019-08-01 (+1d). Complete tasks 0 → 9.

Changed:

| ID | Task | Start | Finish | Duration | Complete | Total float | Other |
| --- | --- | --- | --- | --- | --- | --- | --- |
| 1 | Tegning | 2019-06-20 A | 2019-06-26 A |  | 0% → 100% | 0d → none | baseline start none → 2019-06-20; baseline finish none → 2019-06-26 |
| 2 | **Fundament** | 2019-06-28 A | 2019-07-08 A |  | 0% → 100% | 0d → none | baseline start none → 2019-06-28; baseline finish none → 2019-07-08 |
| 3 | Udgravning | 2019-06-28 A | 2019-07-02 A |  | 0% → 100% | 0d → none | baseline start none → 2019-06-28; baseline finish none → 2019-07-02 |
| 4 | Støbning | 2019-07-02 A | 2019-07-03 A |  | 0% → 100% | 0d → none | baseline start none → 2019-07-02; baseline finish none → 2019-07-03 |
| 5 | Afbinding | 2019-07-03 A | 2019-07-08 A |  | 0% → 100% | 0d → none | baseline start none → 2019-07-03; baseline finish none → 2019-07-08 |
| 6 | **Råhus** | 2019-07-08 A | 2019-07-12 → 2019-07-15 A (+3d) | 4.25d → 5d | 0% → 100% | 0d → none | baseline start none → 2019-07-08; baseline finish none → 2019-07-12 |
| 7 | Bærende konstruktioner | 2019-07-08 A | 2019-07-11 → 2019-07-12 A (+1d) | 3d → 4d | 0% → 100% | 0d → none | baseline start none → 2019-07-08; baseline finish none → 2019-07-11 |
| 8 | Ydervægge | 2019-07-11 A | 2019-07-12 → 2019-07-15 A (+3d) |  | 0% → 100% | 0d → none | baseline start none → 2019-07-11; baseline finish none → 2019-07-12 |
| 9 | Tagkonstruktioner | 2019-07-11 A | 2019-07-12 → 2019-07-15 A (+3d) |  | 0% → 100% | 0d → none | baseline start none → 2019-07-11; baseline finish none → 2019-07-12 |
| 10 | Rejsegilde | 2019-07-12 → 2019-07-15 A (+3d) | 2019-07-15 → 2019-07-16 A (+1d) |  | 0% → 100% | 0d → none | baseline start none → 2019-07-12; baseline finish none → 2019-07-15 |
| 11 | Taglægning |  | 2019-07-29 → 2019-07-30 (+1d) |  |  |  | baseline start none → 2019-07-16; baseline finish none → 2019-07-29 |
| 12 | Døre og vinduer |  | 2019-07-17 → 2019-07-18 (+1d) |  |  | 6.75d → 6.88d | baseline start none → 2019-07-16; baseline finish none → 2019-07-17 |
| 13 | Faskine | 2019-07-03 A | 2019-07-05 A |  | 0% → 100% | 14.38d → none | baseline start none → 2019-07-03; baseline finish none → 2019-07-05 |
| 14 | Tagrender |  | 2019-07-16 → 2019-07-17 (+1d) |  |  |  | baseline start none → 2019-07-16; baseline finish none → 2019-07-16 |
| 15 | Maling udvendigt | 2019-07-26 → 2019-07-29 (+3d) | 2019-07-29 → 2019-07-30 (+1d) |  |  |  | baseline start none → 2019-07-26; baseline finish none → 2019-07-29 |
| 16 | Maling indvendigt |  | 2019-07-19 → 2019-07-22 (+3d) |  |  | 6.75d → 6.88d | baseline start none → 2019-07-18; baseline finish none → 2019-07-19 |
| 17 | Gulv |  |  |  |  | 6.75d → 6.88d | baseline start none → 2019-07-19; baseline finish none → 2019-07-22 |
| 18 | Indvielse | 2019-07-30 → 2019-07-31 (+1d) | 2019-07-31 → 2019-08-01 (+1d) |  |  |  | was named Invielse; baseline start none → 2019-07-30; baseline finish none → 2019-07-31 |

## Version 11 (saved 2020-10-30, file 05A - Opf沴gning I.mpp)

Last finish 2019-08-01 → 2019-07-31 (-1d). Complete tasks 9 → 0.

Changed:

| ID | Task | Start | Finish | Duration | Complete | Total float | Other |
| --- | --- | --- | --- | --- | --- | --- | --- |
| 1 | Tegning | 2019-06-20 A → 2019-06-20 | 2019-06-26 A → 2019-06-26 |  | 100% → 0% | none → 0d | baseline start 2019-06-20 → none; baseline finish 2019-06-26 → none |
| 2 | **Fundament** | 2019-06-28 A → 2019-06-28 | 2019-07-08 A → 2019-07-08 |  | 100% → 0% | none → 0d | baseline start 2019-06-28 → none; baseline finish 2019-07-08 → none |
| 3 | Udgravning | 2019-06-28 A → 2019-06-28 | 2019-07-02 A → 2019-07-02 |  | 100% → 0% | none → 0d | baseline start 2019-06-28 → none; baseline finish 2019-07-02 → none |
| 4 | Støbning | 2019-07-02 A → 2019-07-02 | 2019-07-03 A → 2019-07-03 |  | 100% → 0% | none → 0d | baseline start 2019-07-02 → none; baseline finish 2019-07-03 → none |
| 5 | Afbinding | 2019-07-03 A → 2019-07-03 | 2019-07-08 A → 2019-07-08 |  | 100% → 0% | none → 0d | baseline start 2019-07-03 → none; baseline finish 2019-07-08 → none |
| 6 | **Råhus** | 2019-07-08 A → 2019-07-08 | 2019-07-15 A → 2019-07-12 (-3d) | 5d → 4.25d | 100% → 0% | none → 0d | baseline start 2019-07-08 → none; baseline finish 2019-07-12 → none |
| 7 | Bærende konstruktioner | 2019-07-08 A → 2019-07-08 | 2019-07-12 A → 2019-07-11 (-1d) | 4d → 3d | 100% → 0% | none → 0d | baseline start 2019-07-08 → none; baseline finish 2019-07-11 → none |
| 8 | Ydervægge | 2019-07-11 A → 2019-07-11 | 2019-07-15 A → 2019-07-12 (-3d) |  | 100% → 0% | none → 0d | baseline start 2019-07-11 → none; baseline finish 2019-07-12 → none |
| 9 | Tagkonstruktioner | 2019-07-11 A → 2019-07-11 | 2019-07-15 A → 2019-07-12 (-3d) |  | 100% → 0% | none → 0d | baseline start 2019-07-11 → none; baseline finish 2019-07-12 → none |
| 10 | Rejsegilde | 2019-07-15 A → 2019-07-12 (-3d) | 2019-07-16 A → 2019-07-15 (-1d) |  | 100% → 0% | none → 0d | baseline start 2019-07-12 → none; baseline finish 2019-07-15 → none |
| 11 | Taglægning |  | 2019-07-30 → 2019-07-29 (-1d) |  |  |  | baseline start 2019-07-16 → none; baseline finish 2019-07-29 → none |
| 12 | Døre og vinduer |  | 2019-07-18 → 2019-07-17 (-1d) |  |  | 6.88d → 6.75d | baseline start 2019-07-16 → none; baseline finish 2019-07-17 → none |
| 13 | Faskine | 2019-07-03 A → 2019-07-03 | 2019-07-05 A → 2019-07-05 |  | 100% → 0% | none → 14.38d | baseline start 2019-07-03 → none; baseline finish 2019-07-05 → none |
| 14 | Tagrender |  | 2019-07-17 → 2019-07-16 (-1d) |  |  |  | baseline start 2019-07-16 → none; baseline finish 2019-07-16 → none |
| 15 | Maling udvendigt | 2019-07-29 → 2019-07-26 (-3d) | 2019-07-30 → 2019-07-29 (-1d) |  |  |  | baseline start 2019-07-26 → none; baseline finish 2019-07-29 → none |
| 16 | Maling indvendigt |  | 2019-07-22 → 2019-07-19 (-3d) |  |  | 6.88d → 6.75d | baseline start 2019-07-18 → none; baseline finish 2019-07-19 → none |
| 17 | Gulv |  |  |  |  | 6.88d → 6.75d | baseline start 2019-07-19 → none; baseline finish 2019-07-22 → none |
| 18 | Indvielse | 2019-07-31 → 2019-07-30 (-1d) | 2019-08-01 → 2019-07-31 (-1d) |  |  |  | baseline start 2019-07-30 → none; baseline finish 2019-07-31 → none |

## Version 12 (saved 2020-10-30, file 02B - Mellemliggende tid.mpp)

Last finish 2019-07-31 → 2019-07-25 (-6d).

Changed:

| ID | Task | Start | Finish | Duration | Total float | Predecessors | Other |
| --- | --- | --- | --- | --- | --- | --- | --- |
| 1 | Tegning |  | 2019-06-26 → 2019-06-24 (-2d) |  |  |  | resources Arkitekt Arne → none |
| 2 | **Fundament** | 2019-06-28 → 2019-06-25 (-3d) | 2019-07-08 → 2019-07-04 (-4d) | 6d → 8d |  | 1FS+2d → 1 |  |
| 3 | Udgravning | 2019-06-28 → 2019-06-25 (-3d) | 2019-07-02 → 2019-06-26 (-6d) |  |  |  | resources Gravemaskine; Jord og Beton Jette → none |
| 4 | Støbning | 2019-07-02 → 2019-06-27 (-5d) | 2019-07-03 → 2019-06-27 (-6d) |  |  |  | resources Beton [2 Kubikmeter]; Betonblander; Jord og Beton Jette → none |
| 5 | Afbinding | 2019-07-03 → 2019-06-28 (-5d) | 2019-07-08 → 2019-07-04 (-4d) | 5ed → 5d |  |  |  |
| 6 | **Råhus** | 2019-07-08 → 2019-07-05 (-3d) | 2019-07-12 → 2019-07-11 (-1d) | 4.25d → 5d |  |  |  |
| 7 | Bærende konstruktioner | 2019-07-08 → 2019-07-05 (-3d) | 2019-07-11 → 2019-07-09 (-2d) |  |  |  | resources Tømrer Torben → none |
| 8 | Ydervægge | 2019-07-11 → 2019-07-10 (-1d) | 2019-07-12 → 2019-07-11 (-1d) |  |  | 7FS-2.5% → 7 | resources Murer Mads → none |
| 9 | Tagkonstruktioner | 2019-07-11 → 2019-07-10 (-1d) | 2019-07-12 → 2019-07-11 (-1d) |  |  |  | resources Tømrer Tom → none |
| 10 | Rejsegilde | 2019-07-12 → 2019-07-11 (-1d) | 2019-07-15 → 2019-07-11 (-4d) |  |  |  | resources Arkitekt Arne; Forplejning [10 Kuverter]; Jord og Beton Jette; Maler Morten; Murer Mads; Snedker Susanne; Tømrer Tom; Tømrer Torben; VVS Victoria → none |
| 11 | Taglægning | 2019-07-16 → 2019-07-12 (-4d) | 2019-07-29 → 2019-07-25 (-4d) |  |  |  | resources Tømrer Tom → none |
| 12 | Døre og vinduer | 2019-07-16 → 2019-07-12 (-4d) | 2019-07-17 → 2019-07-15 (-2d) |  | 6.75d → 5d |  |  |
| 13 | Faskine | 2019-07-03 → 2019-06-27 (-6d) | 2019-07-05 → 2019-06-28 (-7d) |  | 14.38d → 17.12d | 4 → 3 | resources Gravemaskine; Jord og Beton Jette → none |
| 14 | Tagrender | 2019-07-16 → 2019-07-12 (-4d) | 2019-07-16 → 2019-07-12 (-4d) |  |  |  | resources VVS Victoria → none |
| 15 | Maling udvendigt | 2019-07-26 → 2019-07-24 (-2d) | 2019-07-29 → 2019-07-25 (-4d) |  |  |  | resources Maling [10 Liter]; Maler Morten → none |
| 16 | Maling indvendigt | 2019-07-18 → 2019-07-16 (-2d) | 2019-07-19 → 2019-07-17 (-2d) |  | 6.75d → 5d |  | resources Maler Morten → none |
| 17 | Gulv | 2019-07-19 → 2019-07-18 (-1d) | 2019-07-22 → 2019-07-18 (-4d) |  | 6.75d → 5d | 16FS-5% → 16 | resources Snedker Susanne → none |
| 18 | Indvielse | 2019-07-30 → 2019-07-25 (-5d) | 2019-07-31 → 2019-07-25 (-6d) |  |  | 17, 15FS+1d → 17, 15 | resources Arkitekt Arne; Betonblander; Forplejning [20 Kuverter]; Gravemaskine; Jord og Beton Jette; Maler Morten; Murer Mads; Snedker Susanne; Tømrer Tom; Tømrer Torben; VVS Victoria → none |

## Version 13 (saved 2020-10-30, file 16 - Butik i Hedensted.mpp)

Last finish 2019-07-25 → 2019-07-29 (+4d).

Changed:

| ID | Task | Start | Finish | Duration | Total float | Predecessors |
| --- | --- | --- | --- | --- | --- | --- |
| 2 | **Fundament** | 2019-06-25 → 2019-06-27 (+2d) | 2019-07-04 → 2019-07-06 (+2d) | 8d → 7d |  | 1 → 1FS+2d |
| 3 | Udgravning | 2019-06-25 → 2019-06-27 (+2d) | 2019-06-26 → 2019-06-28 (+2d) |  | 0d → 1d |  |
| 4 | Støbning | 2019-06-27 → 2019-07-01 (+4d) | 2019-06-27 → 2019-07-01 (+4d) |  | 0d → 1d |  |
| 5 | Afbinding | 2019-06-28 → 2019-07-01 (+3d) | 2019-07-04 → 2019-07-06 (+2d) | 5d → 5ed | 0d → 4.88d |  |
| 6 | **Råhus** | 2019-07-05 → 2019-07-08 (+3d) | 2019-07-11 → 2019-07-12 (+1d) | 5d → 4.25d |  |  |
| 7 | Bærende konstruktioner | 2019-07-05 → 2019-07-08 (+3d) | 2019-07-09 → 2019-07-10 (+1d) |  |  |  |
| 8 | Ydervægge |  | 2019-07-11 → 2019-07-12 (+1d) |  |  | 7 → 7FS-2.5% |
| 9 | Tagkonstruktioner |  | 2019-07-11 → 2019-07-12 (+1d) |  |  |  |
| 10 | Rejsegilde | 2019-07-11 → 2019-07-12 (+1d) | 2019-07-11 → 2019-07-12 (+1d) |  |  |  |
| 11 | Taglægning |  | 2019-07-25 → 2019-07-26 (+1d) |  |  |  |
| 12 | Døre og vinduer |  | 2019-07-15 → 2019-07-16 (+1d) |  | 5d → 7d |  |
| 13 | Faskine | 2019-06-27 → 2019-07-01 (+4d) | 2019-06-28 → 2019-07-02 (+4d) |  | 17.12d → 15.38d |  |
| 15 | Maling udvendigt | 2019-07-24 → 2019-07-25 (+1d) | 2019-07-25 → 2019-07-26 (+1d) |  |  |  |
| 16 | Maling indvendigt |  | 2019-07-17 → 2019-07-18 (+1d) |  | 5d → 7d |  |
| 17 | Gulv | 2019-07-18 → 2019-07-17 (-1d) |  |  | 5d → 7d | 16 → 16FS-5% |
| 18 | Indvielse | 2019-07-25 → 2019-07-29 (+4d) | 2019-07-25 → 2019-07-29 (+4d) |  |  | 17, 15 → 17, 15FS+1d |

## Version 14 (saved 2020-10-30, file 11B - Vis ressourcedetaljer.mpp)

Last finish 2019-07-29 → 2013-09-30 (-2128d).

Added:

| ID | Task | Duration | Start | Finish | Predecessors | Resources |
| --- | --- | --- | --- | --- | --- | --- |
| 1 | Start | 0d | 2013-08-26 | 2013-08-26 |  |  |
| 10 | Tag | 2d | 2013-09-11 | 2013-09-13 | 9SS | Tømrer Tom [25%] |

Removed: 9 Tagkonstruktioner

Changed:

| ID | Task | Start | Finish | Total float | Predecessors | Other |
| --- | --- | --- | --- | --- | --- | --- |
| 2 | Tegning | 2019-06-20 → 2013-08-26 (-2124d) | 2019-06-24 → 2013-08-28 (-2126d) |  | none → 1 | resources none → Arkitekt Arne [50%] |
| 3 | **Fundament** | 2019-06-27 → 2013-08-29 (-2128d) | 2019-07-06 → 2013-09-07 (-2128d) |  | 2FS+2d → 2 |  |
| 4 | Udgravning | 2019-06-27 → 2013-08-29 (-2128d) | 2019-06-28 → 2013-08-30 (-2128d) |  |  | resources none → Gravemaskine; Jord og beton Jette |
| 5 | Støbning | 2019-07-01 → 2013-09-02 (-2128d) | 2019-07-01 → 2013-09-02 (-2128d) |  |  | resources none → Betonblander; Jord og beton Jette |
| 6 | Afbinding | 2019-07-01 → 2013-09-02 (-2128d) | 2019-07-06 → 2013-09-07 (-2128d) |  |  |  |
| 7 | **Råhus** | 2019-07-08 → 2013-09-09 (-2128d) | 2019-07-12 → 2013-09-13 (-2128d) |  | 3 → 6 |  |
| 8 | Bærende konstruktioner | 2019-07-08 → 2013-09-09 (-2128d) | 2019-07-10 → 2013-09-11 (-2128d) |  |  | resources none → Tømrer Tom [25%] |
| 9 | Ydervægge | 2019-07-10 → 2013-09-11 (-2128d) | 2019-07-12 → 2013-09-13 (-2128d) |  |  | resources none → Murer Mads |
| 11 | Rejsegilde | 2019-07-12 → 2013-09-13 (-2128d) | 2019-07-12 → 2013-09-13 (-2128d) |  | 7 → 9, 10 |  |
| 12 | Taglægning | 2019-07-12 → 2013-09-13 (-2128d) | 2019-07-26 → 2013-09-27 (-2128d) |  |  | resources none → Tømrer Tom [50%] |
| 13 | Døre og vinduer | 2019-07-12 → 2013-09-13 (-2128d) | 2019-07-16 → 2013-09-17 (-2128d) | 7d → 5d |  | resources none → Snedker Susanne [25%] |
| 14 | Faskine | 2019-07-01 → 2013-09-03 (-2127d) | 2019-07-02 → 2013-09-04 (-2127d) | 15.38d → 12d | 4 → 5 | resources none → Gravemaskine; Jord og beton Jette |
| 15 | Tagrender | 2019-07-12 → 2013-09-13 (-2128d) | 2019-07-12 → 2013-09-13 (-2128d) | 8.12d → 5.75d |  | resources none → VVS Victoria [25%] |
| 16 | Maling udvendigt | 2019-07-25 → 2013-09-13 (-2141d) | 2019-07-26 → 2013-09-17 (-2138d) | 0d → 5.75d | 15, 12FF → 15 | resources none → Maler Morten |
| 17 | Gulv | 2019-07-17 → 2013-09-17 (-2129d) | 2019-07-18 → 2013-09-18 (-2129d) | 7d → 5d | 18FS-5% → 13, 16FS-5% | resources none → Snedker Susanne [25%] |
| 18 | Maling indvendigt | 2019-07-16 → 2013-09-25 (-2120d) | 2019-07-18 → 2013-09-27 (-2120d) | 7d → 0d | 13 → 12FF, 17 | resources none → Maler Morten |
| 19 | Indvielse | 2019-07-29 → 2013-09-30 (-2128d) | 2019-07-29 → 2013-09-30 (-2128d) |  | 17, 16FS+1d → 13, 18FS+1d |  |

## Version 15 (saved 2022-01-12, file 04A - Formatering.mpp)

Last finish 2013-09-30 → 2018-04-05 (+1648d).

Added:

| ID | Task | Duration | Start | Finish | Predecessors | Resources |
| --- | --- | --- | --- | --- | --- | --- |
| 9 | Tagkonstruktioner | 2d | 2018-03-22 | 2018-03-23 | 8SS | Snedker Susanne |

Removed: 1 Start; 10 Tag

Changed:

| ID | Task | Start | Finish | Duration | Total float | Predecessors | Other |
| --- | --- | --- | --- | --- | --- | --- | --- |
| 1 | Tegning | 2013-08-26 → 2018-03-05 (+1652d) | 2013-08-28 → 2018-03-07 (+1652d) |  | 1d → 0d | Start → none | resources Arkitekt Arne [50%] → Arkitekt Arne |
| 2 | **Fundament** | 2013-08-29 → 2018-03-12 (+1656d) | 2013-09-07 → 2018-03-19 (+1654d) | 7d → 6d |  | 1 → 1FS+2d |  |
| 3 | Udgravning | 2013-08-29 → 2018-03-12 (+1656d) | 2013-08-30 → 2018-03-13 (+1656d) |  | 1d → 0d |  |  |
| 4 | Støbning | 2013-09-02 → 2018-03-14 (+1654d) | 2013-09-02 → 2018-03-14 (+1654d) |  | 1d → 0d |  | resources Betonblander; Jord og beton Jette → Jord og beton Jette; Betonblander |
| 5 | Afbinding | 2013-09-02 → 2018-03-14 (+1654d) | 2013-09-07 → 2018-03-19 (+1654d) |  | 4.88d → 1.88d |  |  |
| 6 | **Råhus** | 2013-09-09 → 2018-03-20 (+1653d) | 2013-09-13 → 2018-03-23 (+1652d) | 4.25d → 4d |  |  |  |
| 7 | Bærende konstruktioner | 2013-09-09 → 2018-03-20 (+1653d) | 2013-09-11 → 2018-03-23 (+1654d) | 3d → 4d |  |  | resources Tømrer Tom [25%] → Tømrer Tom |
| 8 | Ydervægge | 2013-09-11 → 2018-03-22 (+1653d) | 2013-09-13 → 2018-03-23 (+1652d) |  |  | 7FS-2.5% → 7FS-5% |  |
| 10 | Rejsegilde | 2013-09-13 → 2018-03-23 (+1652d) | 2013-09-13 → 2018-03-23 (+1652d) |  |  | 8, Tag → 9 | resources none → Arkitekt Arne; Jord og beton Jette; Maler Morten; Murer Mads; Snedker Susanne; Tømrer Tom; VVS Victoria |
| 11 | Taglægning | 2013-09-13 → 2018-03-26 (+1655d) | 2013-09-27 → 2018-04-04 (+1650d) | 10d → 8d |  |  | resources Tømrer Tom [50%] → Tømrer Tom |
| 12 | Døre og vinduer | 2013-09-13 → 2018-03-26 (+1655d) | 2013-09-17 → 2018-03-27 (+1652d) |  | 5d → 4d |  | resources Snedker Susanne [25%] → Snedker Susanne |
| 13 | Faskine | 2013-09-03 → 2018-03-15 (+1654d) | 2013-09-04 → 2018-03-16 (+1654d) |  | 12d → 9d |  |  |
| 14 | Tagrender | 2013-09-13 → 2018-03-26 (+1655d) | 2013-09-13 → 2018-03-26 (+1655d) | 5h → 1d | 5.75d → 4d |  | resources VVS Victoria [25%] → VVS Victoria |
| 15 | Maling udvendigt | 2013-09-13 → 2018-03-27 (+1656d) | 2013-09-17 → 2018-03-28 (+1653d) | 10h → 2d | 5.75d → 4d |  |  |
| 16 | Gulv | 2013-09-17 → 2018-03-28 (+1653d) | 2013-09-18 → 2018-03-29 (+1653d) | 1d → 2d | 5d → 4d |  | resources Snedker Susanne [25%] → Snedker Susanne |
| 17 | Maling indvendigt | 2013-09-25 → 2018-04-03 (+1651d) | 2013-09-27 → 2018-04-04 (+1650d) |  |  |  |  |
| 18 | Indvielse | 2013-09-30 → 2018-04-05 (+1648d) | 2013-09-30 → 2018-04-05 (+1648d) |  |  | 12, 17FS+1d → 17FS+1d | resources none → Jord og beton Jette; Maler Morten; Murer Mads; Snedker Susanne; Tømrer Tom; VVS Victoria; Arkitekt Arne |

## Version 16 (saved 2022-01-12, file 08A - Ny butik.mpp)

Last finish 2018-04-05 → 2013-09-30 (-1648d).

Added:

| ID | Task | Duration | Start | Finish | Predecessors | Resources |
| --- | --- | --- | --- | --- | --- | --- |
| 1 | Start | 0d | 2013-08-26 | 2013-08-26 |  |  |
| 10 | Tag | 2d | 2013-09-11 | 2013-09-13 | 9SS | Tømrer Tom [25%] |

Removed: 9 Tagkonstruktioner

Changed:

| ID | Task | Start | Finish | Duration | Total float | Predecessors | Other |
| --- | --- | --- | --- | --- | --- | --- | --- |
| 2 | Tegning | 2018-03-05 → 2013-08-26 (-1652d) | 2018-03-07 → 2013-08-28 (-1652d) |  | 0d → 1d | none → 1 | resources Arkitekt Arne → Arkitekt Arne [50%] |
| 3 | **Fundament** | 2018-03-12 → 2013-08-29 (-1656d) | 2018-03-19 → 2013-09-07 (-1654d) | 6d → 7d |  | 2FS+2d → 2 |  |
| 4 | Udgravning | 2018-03-12 → 2013-08-29 (-1656d) | 2018-03-13 → 2013-08-30 (-1656d) |  | 0d → 1d |  |  |
| 5 | Støbning | 2018-03-14 → 2013-09-02 (-1654d) | 2018-03-14 → 2013-09-02 (-1654d) |  | 0d → 1d |  | resources Jord og beton Jette; Betonblander → Betonblander; Jord og beton Jette |
| 6 | Afbinding | 2018-03-14 → 2013-09-02 (-1654d) | 2018-03-19 → 2013-09-07 (-1654d) |  | 1.88d → 4.88d |  |  |
| 7 | **Råhus** | 2018-03-20 → 2013-09-09 (-1653d) | 2018-03-23 → 2013-09-13 (-1652d) | 4d → 4.25d |  |  |  |
| 8 | Bærende konstruktioner | 2018-03-20 → 2013-09-09 (-1653d) | 2018-03-23 → 2013-09-11 (-1654d) | 4d → 3d |  |  | resources Tømrer Tom → Tømrer Tom [25%] |
| 9 | Ydervægge | 2018-03-22 → 2013-09-11 (-1653d) | 2018-03-23 → 2013-09-13 (-1652d) |  |  | 8FS-5% → 8FS-2.5% |  |
| 11 | Rejsegilde | 2018-03-23 → 2013-09-13 (-1652d) | 2018-03-23 → 2013-09-13 (-1652d) |  |  | Tagkonstruktioner → 9, 10 | resources Arkitekt Arne; Jord og beton Jette; Maler Morten; Murer Mads; Snedker Susanne; Tømrer Tom; VVS Victoria → none |
| 12 | Taglægning | 2018-03-26 → 2013-09-13 (-1655d) | 2018-04-04 → 2013-09-27 (-1650d) | 8d → 10d |  |  | resources Tømrer Tom → Tømrer Tom [50%] |
| 13 | Døre og vinduer | 2018-03-26 → 2013-09-13 (-1655d) | 2018-03-27 → 2013-09-17 (-1652d) |  | 4d → 5d |  | resources Snedker Susanne → Snedker Susanne [25%] |
| 14 | Faskine | 2018-03-15 → 2013-09-03 (-1654d) | 2018-03-16 → 2013-09-04 (-1654d) |  | 9d → 12d |  |  |
| 15 | Tagrender | 2018-03-26 → 2013-09-13 (-1655d) | 2018-03-26 → 2013-09-13 (-1655d) | 1d → 5h | 4d → 5.75d |  | resources VVS Victoria → VVS Victoria [25%] |
| 16 | Maling udvendigt | 2018-03-27 → 2013-09-13 (-1656d) | 2018-03-28 → 2013-09-17 (-1653d) | 2d → 10h | 4d → 5.75d |  |  |
| 17 | Gulv | 2018-03-28 → 2013-09-17 (-1653d) | 2018-03-29 → 2013-09-18 (-1653d) | 2d → 1d | 4d → 5d |  | resources Snedker Susanne → Snedker Susanne [25%] |
| 18 | Maling indvendigt | 2018-04-03 → 2013-09-25 (-1651d) | 2018-04-04 → 2013-09-27 (-1650d) |  |  |  |  |
| 19 | Indvielse | 2018-04-05 → 2013-09-30 (-1648d) | 2018-04-05 → 2013-09-30 (-1648d) |  |  | 18FS+1d → 13, 18FS+1d | resources Jord og beton Jette; Maler Morten; Murer Mads; Snedker Susanne; Tømrer Tom; VVS Victoria; Arkitekt Arne → none |

## Version 17 (saved 2022-01-12, file 01 - Projektforslag.mpp)

Last finish 2013-09-30 → 2018-04-12 (+1655d).

Added:

| ID | Task | Duration | Start | Finish | Predecessors | Resources |
| --- | --- | --- | --- | --- | --- | --- |
| 9 | Tagkonstruktioner | 2d | 2018-03-26 | 2018-03-28 | 8SS | Snedker Susanne |

Removed: 1 Start; 19 Indvielse

Changed:

| ID | Task | Start | Finish | Duration | Total float | Predecessors | Other |
| --- | --- | --- | --- | --- | --- | --- | --- |
| 1 | Tegning | 2013-08-26 → 2018-03-05 (+1652d) | 2013-08-28 → 2018-03-09 (+1654d) |  | 1d → 0d | Start → none | resources Arkitekt Arne [50%] → Arkitekt Arne |
| 2 | **Fundament** | 2013-08-29 → 2018-03-13 (+1657d) | 2013-09-07 → 2018-03-21 (+1656d) | 7d → 6d |  | 1 → 1FS+2d |  |
| 3 | Udgravning | 2013-08-29 → 2018-03-13 (+1657d) | 2013-08-30 → 2018-03-15 (+1658d) |  | 1d → 0d |  |  |
| 4 | Støbning | 2013-09-02 → 2018-03-15 (+1655d) | 2013-09-02 → 2018-03-16 (+1656d) |  | 1d → 0d |  | resources Betonblander; Jord og beton Jette → Jord og beton Jette; Betonblander |
| 5 | Afbinding | 2013-09-02 → 2018-03-16 (+1656d) | 2013-09-07 → 2018-03-21 (+1656d) |  | 4.88d → 0d |  |  |
| 6 | **Råhus** | 2013-09-09 → 2018-03-21 (+1654d) | 2013-09-13 → 2018-03-28 (+1657d) | 4.25d → 4.5d |  |  |  |
| 7 | Bærende konstruktioner | 2013-09-09 → 2018-03-21 (+1654d) | 2013-09-11 → 2018-03-26 (+1657d) |  |  |  | resources Tømrer Tom [25%] → Tømrer Tom |
| 8 | Ydervægge | 2013-09-11 → 2018-03-26 (+1657d) | 2013-09-13 → 2018-03-27 (+1656d) |  |  |  |  |
| 10 | Rejsegilde | 2013-09-13 → 2018-03-28 (+1657d) | 2013-09-13 → 2018-03-28 (+1657d) |  |  | 8, 18 → 9 | resources none → Arkitekt Arne; Jord og beton Jette; Maler Morten; Murer Mads; Snedker Susanne; Tømrer Tom; VVS Victoria |
| 11 | Taglægning | 2013-09-13 → 2018-03-28 (+1657d) | 2013-09-27 → 2018-04-11 (+1657d) |  |  |  | resources Tømrer Tom [50%] → Tømrer Tom |
| 12 | Døre og vinduer | 2013-09-13 → 2018-03-28 (+1657d) | 2013-09-17 → 2018-03-30 (+1655d) |  | 5d → 4.5d |  | resources Snedker Susanne [25%] → Snedker Susanne |
| 13 | Faskine | 2013-09-03 → 2018-03-16 (+1655d) | 2013-09-04 → 2018-03-20 (+1658d) |  | 12d → 11.12d |  |  |
| 14 | Tagrender | 2013-09-13 → 2018-03-28 (+1657d) | 2013-09-13 → 2018-03-28 (+1657d) |  | 5.75d → 5.62d |  | resources VVS Victoria [25%] → VVS Victoria |
| 15 | Maling udvendigt | 2013-09-13 → 2018-03-28 (+1657d) | 2013-09-17 → 2018-03-30 (+1655d) |  | 5.75d → 5.62d |  |  |
| 16 | Gulv | 2013-09-17 → 2018-03-30 (+1655d) | 2013-09-18 → 2018-04-02 (+1657d) |  | 5d → 4.62d |  | resources Snedker Susanne [25%] → Snedker Susanne |
| 17 | Maling indvendigt | 2013-09-25 → 2018-04-09 (+1657d) | 2013-09-27 → 2018-04-11 (+1657d) |  |  |  |  |
| 18 | Indflytning | 2013-09-11 → 2018-04-12 (+1674d) | 2013-09-13 → 2018-04-12 (+1672d) | 2d → 0d |  | 8SS → 17FS+1d | was named Tag; resources Tømrer Tom [25%] → Jord og beton Jette; Maler Morten; Murer Mads; Snedker Susanne; Tømrer Tom; VVS Victoria; Arkitekt Arne |

## Version 18 (saved 2022-01-12, file 12A - Ny butik rapporter.mpp)

Last finish 2018-04-12 → 2018-04-05 (-7d). Complete tasks 0 → 2.

Changed:

| ID | Task | Start | Finish | Duration | Complete | Total float | Predecessors | Other |
| --- | --- | --- | --- | --- | --- | --- | --- | --- |
| 1 | Tegning | 2018-03-05 A | 2018-03-09 → 2018-03-07 A (-2d) |  | 0% → 100% | 0d → none |  |  |
| 2 | **Fundament** | 2018-03-13 → 2018-03-12 A (-1d) | 2018-03-21 → 2018-03-19 (-2d) |  | 0% → 54% | 0d → 0.5d |  |  |
| 3 | Udgravning | 2018-03-13 → 2018-03-12 A (-1d) | 2018-03-15 → 2018-03-13 (-2d) |  | 0% → 75% | 0d → 0.75d |  |  |
| 4 | Støbning | 2018-03-15 → 2018-03-14 A (-1d) | 2018-03-16 → 2018-03-14 (-2d) |  | 0% → 75% | 0d → 2d |  |  |
| 5 | Afbinding | 2018-03-16 → 2018-03-14 A (-2d) | 2018-03-21 → 2018-03-19 (-2d) |  | 0% → 50% | 0d → 2.5d |  |  |
| 6 | **Råhus** | 2018-03-21 → 2018-03-20 A (-1d) | 2018-03-28 → 2018-03-23 (-5d) | 4.5d → 4d | 0% → 6% | 0d → 9d |  |  |
| 7 | Bærende konstruktioner | 2018-03-21 → 2018-03-20 (-1d) | 2018-03-26 → 2018-03-23 (-3d) | 3d → 4d |  | 0d → 0.5d |  |  |
| 8 | Ydervægge | 2018-03-26 → 2018-03-22 A (-4d) | 2018-03-27 → 2018-03-23 (-4d) |  | 0% → 25% | 0d → 9d | 7FS-2.5% → 7FS-5% |  |
| 9 | Tagkonstruktioner | 2018-03-26 → 2018-03-22 (-4d) | 2018-03-28 → 2018-03-23 (-5d) |  |  |  |  |  |
| 10 | Rejsegilde | 2018-03-28 → 2018-03-23 (-5d) | 2018-03-28 → 2018-03-23 (-5d) |  |  |  |  |  |
| 11 | Taglægning | 2018-03-28 → 2018-03-26 (-2d) | 2018-04-11 → 2018-04-04 (-7d) | 10d → 8d |  |  |  |  |
| 12 | Døre og vinduer | 2018-03-28 → 2018-03-26 (-2d) | 2018-03-30 → 2018-03-27 (-3d) |  |  | 4.5d → 2d |  |  |
| 13 | Faskine | 2018-03-16 → 2018-03-15 A (-1d) | 2018-03-20 → 2018-03-16 A (-4d) |  | 0% → 100% | 11.12d → none |  |  |
| 14 | Tagrender | 2018-03-28 → 2018-03-26 (-2d) | 2018-03-28 → 2018-03-26 (-2d) | 5h → 1d |  | 5.62d → 2d |  |  |
| 15 | Maling udvendigt | 2018-03-28 → 2018-03-27 (-1d) | 2018-03-30 → 2018-03-28 (-2d) | 10h → 2d |  | 5.62d → 2d |  |  |
| 16 | Gulv | 2018-03-30 → 2018-03-28 (-2d) | 2018-04-02 → 2018-03-29 (-4d) | 1d → 2d |  | 4.62d → 2d |  |  |
| 17 | Maling indvendigt | 2018-04-09 → 2018-04-03 (-6d) | 2018-04-11 → 2018-04-04 (-7d) |  |  |  |  |  |
| 18 | Indvielse | 2018-04-12 → 2018-04-05 (-7d) | 2018-04-12 → 2018-04-05 (-7d) |  |  |  |  | was named Indflytning |

## Version 19 (saved 2022-01-12, file 13 - Deltidskalender.mpp)

Last finish 2018-04-05 → 2019-07-31 (+482d). Complete tasks 2 → 0.

Changed:

| ID | Task | Start | Finish | Duration | Complete | Total float | Predecessors | Other |
| --- | --- | --- | --- | --- | --- | --- | --- | --- |
| 1 | Tegning | 2018-03-05 A → 2019-06-20 (+472d) | 2018-03-07 A → 2019-06-26 (+476d) |  | 100% → 0% | none → 0d |  |  |
| 2 | **Fundament** | 2018-03-12 A → 2019-06-28 (+473d) | 2018-03-19 → 2019-07-08 (+476d) |  | 54% → 0% | 0.5d → 0d |  |  |
| 3 | Udgravning | 2018-03-12 A → 2019-06-28 (+473d) | 2018-03-13 → 2019-07-02 (+476d) |  | 75% → 0% | 0.75d → 0d |  | resources Gravemaskine; Jord og beton Jette → Gravemaskine; Jord og Beton Jette |
| 4 | Støbning | 2018-03-14 A → 2019-07-02 (+475d) | 2018-03-14 → 2019-07-03 (+476d) |  | 75% → 0% | 2d → 0d |  | resources Jord og beton Jette; Betonblander → Beton [2 Kubikmeter]; Betonblander; Jord og Beton Jette |
| 5 | Afbinding | 2018-03-14 A → 2019-07-03 (+476d) | 2018-03-19 → 2019-07-08 (+476d) |  | 50% → 0% | 2.5d → 0d |  |  |
| 6 | **Råhus** | 2018-03-20 A → 2019-07-08 (+475d) | 2018-03-23 → 2019-07-12 (+476d) | 4d → 4.25d | 6% → 0% | 9d → 0d | 5 → 2 |  |
| 7 | Bærende konstruktioner | 2018-03-20 → 2019-07-08 (+475d) | 2018-03-23 → 2019-07-11 (+475d) | 4d → 3d |  | 0.5d → 0d |  | resources Tømrer Tom → Tømrer Torben |
| 8 | Ydervægge | 2018-03-22 A → 2019-07-11 (+476d) | 2018-03-23 → 2019-07-12 (+476d) |  | 25% → 0% | 9d → 0d | 7FS-5% → 7FS-2.5% |  |
| 9 | Tagkonstruktioner | 2018-03-22 → 2019-07-11 (+476d) | 2018-03-23 → 2019-07-12 (+476d) |  |  |  |  | resources Snedker Susanne → Tømrer Tom |
| 10 | Rejsegilde | 2018-03-23 → 2019-07-12 (+476d) | 2018-03-23 → 2019-07-15 (+479d) |  |  |  | 9 → 6 | resources Arkitekt Arne; Jord og beton Jette; Maler Morten; Murer Mads; Snedker Susanne; Tømrer Tom; VVS Victoria → Arkitekt Arne; Forplejning [10 Kuverter]; Jord og Beton Jette; Maler Morten; Murer Mads; Snedker Susanne; Tømrer Tom; Tømrer Torben; VVS Victoria |
| 11 | Taglægning | 2018-03-26 → 2019-07-16 (+477d) | 2018-04-04 → 2019-07-29 (+481d) | 8d → 10d |  |  |  |  |
| 12 | Døre og vinduer | 2018-03-26 → 2019-07-16 (+477d) | 2018-03-27 → 2019-07-17 (+477d) |  |  | 2d → 6.75d |  | resources Snedker Susanne → none |
| 13 | Faskine | 2018-03-15 A → 2019-07-03 (+475d) | 2018-03-16 A → 2019-07-05 (+476d) |  | 100% → 0% | none → 14.38d |  | resources Gravemaskine; Jord og beton Jette → Gravemaskine; Jord og Beton Jette |
| 14 | Tagrender | 2018-03-26 → 2019-07-16 (+477d) | 2018-03-26 → 2019-07-16 (+477d) | 1d → 5h |  | 2d → 8.12d |  |  |
| 15 | Maling udvendigt | 2018-03-27 → 2019-07-26 (+486d) | 2018-03-28 → 2019-07-29 (+488d) | 2d → 10h |  | 2d → 0d | 14 → 14, 11FF | resources Maler Morten → Maling [10 Liter]; Maler Morten |
| 16 | Maling indvendigt | 2018-04-03 → 2019-07-18 (+471d) | 2018-04-04 → 2019-07-19 (+471d) |  |  | 0d → 6.75d | 17, 11FF → 12 |  |
| 17 | Gulv | 2018-03-28 → 2019-07-19 (+478d) | 2018-03-29 → 2019-07-22 (+480d) | 2d → 1d |  | 2d → 6.75d | 15FS-5%, 12 → 16FS-5% |  |
| 18 | Indvielse | 2018-04-05 → 2019-07-30 (+481d) | 2018-04-05 → 2019-07-31 (+482d) |  |  |  | 16FS+1d → 17, 15FS+1d | resources Jord og beton Jette; Maler Morten; Murer Mads; Snedker Susanne; Tømrer Tom; VVS Victoria; Arkitekt Arne → Arkitekt Arne; Betonblander; Forplejning [20 Kuverter]; Gravemaskine; Jord og Beton Jette; Maler Morten; Murer Mads; Snedker Susanne; Tømrer Tom; Tømrer Torben; VVS Victoria |

## Version 20 (saved 2022-01-12, file 18B - Rapporter.mpp)

Last finish 2019-07-31 → 2008-10-27 (-3929d). Complete tasks 0 → 1.

Added:

| ID | Task | Duration | Start | Finish | Predecessors | Resources |
| --- | --- | --- | --- | --- | --- | --- |
| 1 | Start | 0d | 2008-09-23 | 2008-09-23 |  |  |
| 10 | Tag | 2d | 2008-10-08 | 2008-10-10 | 9SS | Snedker Susanne |

Removed: 9 Tagkonstruktioner

Changed:

| ID | Task | Start | Finish | Duration | Complete | Total float | Predecessors | Other |
| --- | --- | --- | --- | --- | --- | --- | --- | --- |
| 2 | Tegning | 2019-06-20 → 2008-09-23 A (-3922d) | 2019-06-26 → 2008-09-25 A (-3926d) |  | 0% → 100% | 0d → none | none → 1 |  |
| 3 | **Fundament** | 2019-06-28 → 2008-09-26 A (-3927d) | 2019-07-08 → 2008-10-05 (-3928d) |  | 0% → 53% | 0d → 0.5d | 2FS+2d → 2 |  |
| 4 | Udgravning | 2019-06-28 → 2008-09-26 A (-3927d) | 2019-07-02 → 2008-09-29 (-3928d) |  | 0% → 75% | 0d → 0.5d |  | resources Gravemaskine; Jord og Beton Jette → Jord og beton Jette; Gravemaskine |
| 5 | Støbning | 2019-07-02 → 2008-09-30 A (-3927d) | 2019-07-03 → 2008-09-30 (-3928d) |  | 0% → 50% | 0d → 2d |  | resources Beton [2 Kubikmeter]; Betonblander; Jord og Beton Jette → Jord og beton Jette; Betonblander |
| 6 | Afbinding | 2019-07-03 → 2008-09-30 A (-3928d) | 2019-07-08 → 2008-10-05 (-3928d) |  | 0% → 50% | 0d → 2.5d |  |  |
| 7 | **Råhus** | 2019-07-08 → 2008-10-06 A (-3927d) | 2019-07-12 → 2008-10-10 (-3927d) | 4.25d → 4.5d | 0% → 7% |  | 3 → 6 |  |
| 8 | Bærende konstruktioner | 2019-07-08 → 2008-10-06 (-3927d) | 2019-07-11 → 2008-10-08 (-3928d) |  |  | 0d → 0.5d |  | resources Tømrer Torben → Tømrer Tom |
| 9 | Ydervægge | 2019-07-11 → 2008-10-08 A (-3928d) | 2019-07-12 → 2008-10-10 (-3927d) |  | 0% → 25% | 0d → 0.25d |  |  |
| 11 | Rejsegilde | 2019-07-12 → 2008-10-10 (-3927d) | 2019-07-15 → 2008-10-10 (-3930d) |  |  |  | 7 → 10, 9 | resources Arkitekt Arne; Forplejning [10 Kuverter]; Jord og Beton Jette; Maler Morten; Murer Mads; Snedker Susanne; Tømrer Tom; Tømrer Torben; VVS Victoria → Jord og beton Jette; Maler Morten; Murer Mads; Snedker Susanne; Tømrer Tom; VVS Victoria |
| 12 | Taglægning | 2019-07-16 → 2008-10-10 (-3931d) | 2019-07-29 → 2008-10-24 (-3930d) |  |  |  |  |  |
| 13 | Døre og vinduer | 2019-07-16 → 2008-10-10 (-3931d) | 2019-07-17 → 2008-10-14 (-3928d) |  |  | 6.75d → 4.62d |  | resources none → Snedker Susanne |
| 14 | Faskine | 2019-07-03 → 2008-10-01 (-3927d) | 2019-07-05 → 2008-10-02 (-3928d) |  |  | 14.38d → 11.12d |  | resources Gravemaskine; Jord og Beton Jette → Jord og beton Jette; Gravemaskine |
| 15 | Tagrender | 2019-07-16 → 2008-10-10 (-3931d) | 2019-07-16 → 2008-10-13 (-3928d) |  |  | 8.12d → 5.62d |  |  |
| 16 | Maling udvendigt | 2019-07-26 → 2008-10-13 (-3938d) | 2019-07-29 → 2008-10-14 (-3940d) |  |  | 0d → 5.62d | 15, 12FF → 15 | resources Maling [10 Liter]; Maler Morten → Maler Morten |
| 17 | Gulv | 2019-07-19 → 2008-10-14 (-3930d) | 2019-07-22 → 2008-10-15 (-3932d) |  |  | 6.75d → 4.62d | 18FS-5% → 16FS-5%, 13 |  |
| 18 | Maling indvendigt | 2019-07-18 → 2008-10-22 (-3921d) | 2019-07-19 → 2008-10-24 (-3920d) |  |  | 6.75d → 0d | 13 → 17, 12FF |  |
| 19 | Indvielse | 2019-07-30 → 2008-10-27 (-3928d) | 2019-07-31 → 2008-10-27 (-3929d) |  |  |  | 17, 16FS+1d → 18FS+1d, 13 | resources Arkitekt Arne; Betonblander; Forplejning [20 Kuverter]; Gravemaskine; Jord og Beton Jette; Maler Morten; Murer Mads; Snedker Susanne; Tømrer Tom; Tømrer Torben; VVS Victoria → Jord og beton Jette; Maler Morten; Murer Mads; Snedker Susanne; Tømrer Tom; VVS Victoria |
